# tutorial 1

How a schedule from MS Project changed from version to version. A marks actual dates.

## Version 1 (saved 2010-06-29)

| ID | WBS | Task | Duration | Start | Finish | Predecessors | Total float |
| --- | --- | --- | --- | --- | --- | --- | --- |
| 1 | 1 | **tutorial 1** | 224d | 2010-06-29 | 2011-05-06 |  | 0d |
| 2 |  | footgrid A | 24d | 2010-06-29 | 2010-07-30 |  | 8d |
| 3 |  | basement | 94d | 2010-06-29 | 2010-11-05 |  | 0d |
| 4 |  | manufacture | 130d | 2010-06-29 | 2010-12-27 |  | 26d |
| 5 |  | footgridB | 32d | 2010-08-02 | 2010-09-14 | 2 | 8d |
| 6 |  | columnA 0 | 15d | 2010-08-02 | 2010-08-20 | 2 | 27d |
| 7 |  | footgridC | 20d | 2010-09-15 | 2010-10-12 | 5 | 8d |
| 8 |  | columnB 0 | 18d | 2010-09-15 | 2010-10-08 | 5, 6 | 10d |
| 9 |  | columnC 0 | 12d | 2010-10-13 | 2010-10-28 | 7, 8 | 8d |
| 10 |  | galfloor | 30d | 2010-10-13 | 2010-11-23 | 7, 8 | 12d |
| 11 |  | hall office floor | 42d | 2010-11-08 | 2011-01-04 | 3, 9 | 2d |
| 12 |  | hall access floor | 24d | 2010-11-08 | 2010-12-09 | 3, 8, 7 | 0d |
| 13 |  | columnB 4 | 20d | 2010-12-10 | 2011-01-06 | 10, 12 | 0d |
| 14 |  | columnC 4 | 18d | 2011-01-07 | 2011-02-01 | 11, 13 | 0d |
| 15 |  | erectpre | 14d | 2011-02-02 | 2011-02-21 | 14, 4 | 0d |
| 16 |  | columnB 8 | 18d | 2011-02-22 | 2011-03-17 | 15 | 0d |
| 17 |  | columnA 8 | 22d | 2011-02-02 | 2011-03-03 | 14, 4 | 10d |
| 18 |  | galleryhouse | 36d | 2011-03-18 | 2011-05-06 | 17, 16 | 0d |

## Version 2 (saved 2012-04-23)

Last finish 2011-05-06 → 2012-11-22 (+566d).

Added:

| ID | Task | Duration | Start | Finish | Predecessors | Resources |
| --- | --- | --- | --- | --- | --- | --- |
| 1 | **RUMAH BANGLO KELAS D 2 TINGKAT** | 234d | 2012-01-02 | 2012-11-22 |  |  |
| 16 | **Earthwork** | 16d | 2012-02-01 | 2012-02-22 |  |  |
| 17 | cut and fill | 5d | 2012-02-01 | 2012-02-07 | 15 | Excavator; Excavator Operator; General Labour [200%]; Lorry; Backhoe; Backhoe Driver |
| 18 | levelling | 2d | 2012-02-08 | 2012-02-09 | 17 | Skill Worker; General Labour [200%]; Compactor |
| 19 | grading | 2d | 2012-02-10 | 2012-02-13 | 18 | Skill Worker; General Labour |
| 20 | compacting | 5d | 2012-02-14 | 2012-02-20 | 19 | Compactor; General Labour |
| 21 | excavate the temporary earth drain | 2d | 2012-02-21 | 2012-02-22 | 20 | Excavator; Excavator Operator |
| 22 | **SUB-STRUCTURE** | 36d | 2012-02-23 | 2012-04-12 |  |  |
| 23 | **Piling Works** | 14d | 2012-02-23 | 2012-03-13 |  |  |
| 24 | **Driven Piles (Type 1)** | 13d | 2012-02-23 | 2012-03-12 |  |  |
| 25 | Driven Piles | 8d | 2012-02-23 | 2012-03-05 | 20, 21 | Driven piling machine; 200x200mm Precast concrete piles <3m [600%] |
| 26 | Cut Off surplus length | 1d | 2012-03-06 | 2012-03-06 | 25 | General Labour; Cutting pile machine |
| 27 | Load Testing (PDA) | 3d | 2012-03-08 | 2012-03-12 | 26FS+1d | Skill Worker |
| 28 | **Driven Piles (Type 2)** | 6d | 2012-03-06 | 2012-03-13 |  |  |
| 29 | Driven Piles | 2d | 2012-03-06 | 2012-03-07 | 25 | Driven piling machine; 150x150mm Precast concrete piles <3m [600%] |
| 30 | Cut Off surplus length | 1d | 2012-03-08 | 2012-03-08 | 29 | Cutting pile machine; General Labour |
| 31 | Load Testing (PDA) | 3d | 2012-03-09 | 2012-03-13 | 30 | Skill Worker |
| 32 | **Pile Cap** | 14d | 2012-03-14 | 2012-04-02 |  |  |
| 33 | Backfill & Platform Leveling ( Before laying Lean Concrete) | 2d | 2012-03-14 | 2012-03-15 | 27, 31 | General Labour [300%] |
| 34 | Anti- Terminte Chemical soil treatment | 2d | 2012-03-14 | 2012-03-15 | 33FF | Anti-termite |
| 35 | Lean Concrete | 2d | 2012-03-16 | 2012-03-19 | 34 | General Labour [200%]; Concrete G15 [400%] |
| 36 | Polythene Sheet damp Proof Membrance | 1d | 2012-03-20 | 2012-03-20 | 35 | Damp proof membrance; General Labour [200%] |
| 37 | Formwork | 1d | 2012-03-21 | 2012-03-21 | 36 | Formwork [2000%]; General Labour [200%] |
| 38 | Rebars | 3d | 2012-03-22 | 2012-03-26 | 37 | Formwork [10000%]; General Labour [200%] |
| 39 | Concrete | 1d | 2012-03-27 | 2012-03-27 | 38 | Formwork [1000%]; General Labour [400%] |
| 40 | Curing | 3d | 2012-03-28 | 2012-03-30 | 39 | General Labour |
| 41 | Dismantle Formwork | 1d | 2012-04-02 | 2012-04-02 | 40 | General Labour [200%] |
| 42 | **Column Stump** | 8d | 2012-04-03 | 2012-04-12 |  |  |
| 43 | Formwork | 1d | 2012-04-03 | 2012-04-03 | 41 | Formwork [2000%]; General Labour [200%] |
| 44 | Rebars | 2d | 2012-04-04 | 2012-04-05 | 43 | 16mm rebars [10000%]; General Labour [400%] |
| 45 | Concrete | 1d | 2012-04-06 | 2012-04-06 | 44 | Concrete G 30 [500%]; General Labour [200%] |
| 46 | Curing | 3d | 2012-04-09 | 2012-04-11 | 45 | General Labour |
| 47 | Dismantle Formwork | 1d | 2012-04-12 | 2012-04-12 | 46 | General Labour [300%] |
| 48 | **SUPERSTRUCTURE** | 143d | 2012-04-03 | 2012-10-18 |  |  |
| 49 | **Ground Floor Beams** | 19d | 2012-04-03 | 2012-04-27 |  |  |
| 50 | Anti- Terminte | 1d | 2012-04-03 | 2012-04-03 | 41 | Anti-termite |
| 51 | Concrete Topping | 3d | 2012-04-04 | 2012-04-06 | 50 | Concrete G15 [500%]; General Labour [200%] |
| 52 | Damp Proof Membrance | 1d | 2012-04-09 | 2012-04-09 | 51 | Damp proof membrance |
| 53 | Formwork | 2d | 2012-04-10 | 2012-04-11 | 52 | Formwork [500%]; General Labour [200%]; Coats Cold Bitumen [42800%] |
| 54 | Rebars | 5d | 2012-04-12 | 2012-04-18 | 53 | 16mm rebars [10000%]; General Labour [300%]; Stirrups [83400%] |
| 55 | Concrete | 3d | 2012-04-19 | 2012-04-23 | 54 | General Labour [200%]; Plain concrete Grade 7 [1500%] |
| 56 | Curing | 3d | 2012-04-24 | 2012-04-26 | 55 | General Labour |
| 57 | Dismantle Formwork | 1d | 2012-04-27 | 2012-04-27 | 56 | Carpenter and Joiner |
| 58 | **Ground Floor Slabs** | 42d | 2012-04-03 | 2012-05-30 |  |  |
| 59 | Anti-Termite | 1d | 2012-04-03 | 2012-04-03 | 50SS | Anti-termite |
| 60 | Concrete Topping | 3d | 2012-04-30 | 2012-05-02 | 57, 59 | Concrete G15 [500%]; General Labour [200%] |
| 61 | Service Pipes | 2d | 2012-05-03 | 2012-05-04 | 60 | Plumber; 100mm diam UPVC [1000%] |
| 62 | Damp Proof Membrane | 2d | 2012-05-07 | 2012-05-08 | 61 | Damp proof membrance |
| 63 | Formwork | 2d | 2012-05-09 | 2012-05-10 | 62 | Formwork [1500%]; General Labour [200%]; Coats Cold Bitumen [42800%] |
| 64 | Rebars | 5d | 2012-05-11 | 2012-05-17 | 63 | 16mm rebars [10000%]; General Labour [200%] |
| 65 | Concrete | 5d | 2012-05-18 | 2012-05-24 | 64 | Concrete G 30 [500%]; General Labour [200%] |
| 66 | Curing | 3d | 2012-05-25 | 2012-05-29 | 65 | General Labour |
| 67 | Dismantile Formwork | 1d | 2012-05-30 | 2012-05-30 | 66 | Carpenter and Joiner |
| 68 | **Ground Floor Columns** | 18d | 2012-05-31 | 2012-06-25 |  |  |
| 69 | Formwork | 2d | 2012-05-31 | 2012-06-01 | 47, 67 | Formwork [1500%]; General Labour [200%]; Coats Cold Bitumen [42800%] |
| 70 | Rebars | 5d | 2012-06-04 | 2012-06-08 | 69 | 16mm rebars [10000%]; General Labour [200%] |
| 71 | Service Pipe | 3d | 2012-06-11 | 2012-06-13 | 70 | Plumber; 100mm diam UPVC [1000%] |
| 72 | Concrete | 4d | 2012-06-14 | 2012-06-19 | 71 | Concrete G 30 [1000%]; General Labour [300%] |
| 73 | Curing | 3d | 2012-06-20 | 2012-06-22 | 72 | General Labour |
| 74 | Dismantle Formwork | 1d | 2012-06-25 | 2012-06-25 | 73 | Carpenter and Joiner |
| 75 | **First Floor Beams** | 21d | 2012-06-26 | 2012-07-24 |  |  |
| 76 | Concrete Topping | 3d | 2012-06-26 | 2012-06-28 | 74 | Concrete G15 [500%]; General Labour [200%] |
| 77 | Damp Proof Membrance | 2d | 2012-06-29 | 2012-07-02 | 76 | Damp proof membrance |
| 78 | Formwork | 2d | 2012-07-03 | 2012-07-04 | 77 | Formwork [2000%]; General Labour [200%]; Coats Cold Bitumen [42800%] |
| 79 | Rebars | 5d | 2012-07-05 | 2012-07-11 | 78 | 16mm rebars [2000%]; General Labour [300%]; Stirrups [83400%] |
| 80 | Concrete | 5d | 2012-07-12 | 2012-07-18 | 79 | Concrete G 30 [1000%]; General Labour [300%] |
| 81 | Curing | 3d | 2012-07-19 | 2012-07-23 | 80 | General Labour |
| 82 | Dismantle Formwork | 1d | 2012-07-24 | 2012-07-24 | 81 | Carpenter and Joiner |
| 83 | **First Floor Slabs** | 24d | 2012-07-25 | 2012-08-27 |  |  |
| 84 | Formwork | 2d | 2012-07-25 | 2012-07-26 | 82 |  |
| 85 | Concrete Topping | 2d | 2012-07-27 | 2012-07-30 | 84 | Concrete G15; General Labour [200%] |
| 86 | Service Pipes | 3d | 2012-07-31 | 2012-08-02 | 85 | Plumber [200%]; 100mm diam UPVC [300%] |
| 87 | Damp Proof Membrane | 2d | 2012-08-03 | 2012-08-06 | 86 | Damp proof membrance [200%]; General Labour |
| 88 | Rebars | 5d | 2012-08-07 | 2012-08-13 | 87 | 16mm rebars [10000%]; General Labour [300%] |
| 89 | Concrete | 6d | 2012-08-14 | 2012-08-21 | 88 | Concrete G 30 [200%]; General Labour [200%] |
| 90 | Curing | 3d | 2012-08-22 | 2012-08-24 | 89 | General Labour |
| 91 | Dismantile Formwork | 1d | 2012-08-27 | 2012-08-27 | 90 | General Labour [200%] |
| 92 | **First Floor Columns** | 16d | 2012-08-23 | 2012-09-13 |  |  |
| 93 | Formwork | 2d | 2012-08-23 | 2012-08-24 | 89FS+1d | Formwork [500%]; General Labour [200%]; Carpenter and Joiner; Coats Cold Bitumen [42800%] |
| 94 | Rebars | 5d | 2012-08-27 | 2012-08-31 | 93 | 16mm rebars [6500%]; General Labour [300%] |
| 95 | Concrete | 5d | 2012-09-03 | 2012-09-07 | 94 | Concrete G 30 [200%]; General Labour [300%] |
| 96 | Curing | 3d | 2012-09-10 | 2012-09-12 | 95 | General Labour |
| 97 | Dismantle Formwork | 1d | 2012-09-13 | 2012-09-13 | 96 | General Labour [200%] |
| 98 | **Roof Beam** | 12d | 2012-09-14 | 2012-10-01 |  |  |
| 99 | Formwork | 1d | 2012-09-14 | 2012-09-17 | 95FS+1d, 97 | Formwork [2000%]; General Labour [400%]; Carpenter and Joiner [200%] |
| 100 | Rebars | 4d | 2012-09-18 | 2012-09-21 | 99 | General Labour [400%]; 10mm rebars [93800%] |
| 101 | Concrete | 2d | 2012-09-24 | 2012-09-25 | 100 | Concrete G 30 [1800%]; General Labour [200%] |
| 102 | Curing | 3d | 2012-09-26 | 2012-09-28 | 101 | General Labour |
| 103 | Dismantle formwork | 1d | 2012-10-01 | 2012-10-01 | 102 | General Labour [200%] |
| 104 | **Roof Slab** | 13d | 2012-10-02 | 2012-10-18 |  |  |
| 105 | Formwork | 2d | 2012-10-02 | 2012-10-03 | 103 | Formwork [800%]; General Labour [300%]; Carpenter and Joiner |
| 106 | Rebars | 3d | 2012-10-04 | 2012-10-08 | 105 | General Labour [400%]; 10mm rebars [56800%] |
| 107 | Concrete | 3d | 2012-10-09 | 2012-10-11 | 106 | Concrete G 30 [2000%]; General Labour [300%] |
| 108 | Curing | 3d | 2012-10-12 | 2012-10-16 | 107 | General Labour |
| 109 | Dismantle formwork | 1d | 2012-10-17 | 2012-10-17 | 108 | General Labour [300%] |
| 110 | Water proofing and Asphalt work | 1d | 2012-10-18 | 2012-10-18 | 109 | Water proofing [2000%]; General Labour [200%] |
| 111 | **Staircase** | 13d | 2012-08-28 | 2012-09-13 |  |  |
| 112 | Formwork | 2d | 2012-08-28 | 2012-08-29 | 91 | Formwork [800%]; General Labour [300%]; Carpenter and Joiner |
| 113 | Rebars | 5d | 2012-08-30 | 2012-09-05 | 112 | 16mm rebars [10800%]; General Labour [300%]; 12mm rebars [83200%]; 10mm rebars [800%] |
| 114 | Concrete | 2d | 2012-09-06 | 2012-09-07 | 113 | Concrete G 30 [1000%]; General Labour [300%] |
| 115 | Curing | 3d | 2012-09-10 | 2012-09-12 | 114 | General Labour |
| 116 | Dismantle formwork | 1d | 2012-09-13 | 2012-09-13 | 115 | General Labour [200%] |
| 117 | **Ground Floor Wall** | 10d | 2012-08-28 | 2012-09-10 |  |  |
| 118 | **external wall** | 10d | 2012-08-28 | 2012-09-10 |  |  |
| 119 | levelling | 2d | 2012-08-28 | 2012-08-29 | 112SS | General Labour [200%]; levelling tools [500%] |
| 120 | brickworks | 5d | 2012-09-04 | 2012-09-10 | 119FS+3d | Bricklayer [300%]; General Labour [300%]; Half brickwall 1:6 [7000%]; half brick thick in cement mortar (1:3) [44400%] |
| 121 | **internal wall** | 10d | 2012-08-28 | 2012-09-10 |  |  |
| 122 | levelling | 2d | 2012-08-28 | 2012-08-29 | 119SS | General Labour [200%]; levelling tools [500%] |
| 123 | brickworks | 5d | 2012-09-04 | 2012-09-10 | 122FS+3d | Bricklayer [300%]; General Labour [300%]; half brick thick in cement mortar (1:3) [35800%] |
| 124 | **First Floor Wall** | 9d | 2012-09-11 | 2012-09-21 |  |  |
| 125 | **external wall** | 9d | 2012-09-11 | 2012-09-21 |  |  |
| 126 | levelling | 1d | 2012-09-11 | 2012-09-11 | 123 | General Labour [200%]; levelling tools [500%] |
| 127 | brickworks | 5d | 2012-09-17 | 2012-09-21 | 126FS+3d | Bricklayer [300%]; Half brickwall 1:6 [7000%]; General Labour [300%]; half brick thick in cement mortar (1:3) [44400%] |
| 128 | **internal wall** | 8d | 2012-09-11 | 2012-09-20 |  |  |
| 129 | levelling | 2d | 2012-09-11 | 2012-09-12 | 126SS | General Labour [200%]; levelling tools [500%] |
| 130 | brickworks | 5d | 2012-09-14 | 2012-09-20 | 129SS+3d | Bricklayer [300%]; General Labour [300%]; half brick thick in cement mortar (1:3) [35800%] |
| 131 | **Window** | 12d | 2012-09-11 | 2012-09-26 |  |  |
| 132 | **ground floor** | 3d | 2012-09-11 | 2012-09-13 |  |  |
| 133 | frame | 2d | 2012-09-11 | 2012-09-12 | 120 | General Labour [200%]; Mild steel window grille 600x600mm Type GTA14 [200%]; Mild steel window grille1200x600mm Type GTA15 [800%]; Skill Worker [200%]; Window hunger 600x560mm Type TA14 [600%]; Window hunger 1200x560mm Type TA15 [1000%]; Window 1800x1800mm Type TA8a [1600%]; Window 600x1200mm (side hung window)Type TA1a [200%]; Ironmongery for window [8800%] |
| 134 | glass | 1d | 2012-09-13 | 2012-09-13 | 133 | General Labour [200%]; Glazing compound [3800%]; Glazing strip and silicon topping 0.1-0.5m2 [2600%]; Glazing strip and silicon topping 0.5-1m2 [3400%]; Skill Worker [200%] |
| 135 | **1st floor** | 3d | 2012-09-24 | 2012-09-26 |  |  |
| 136 | frame | 2d | 2012-09-24 | 2012-09-25 | 127 | General Labour [200%]; Mild steel window grille 600x600mm Type GTA14 [200%]; Mild steel window grille1200x600mm Type GTA15 [800%]; Skill Worker [200%]; Window hunger 600x560mm Type TA14 [600%]; Window hunger 1200x560mm Type TA15 [1000%]; Window 1800x1800mm Type TA8a [1600%]; Window 600x1200mm (side hung window)Type TA1a [200%]; Ironmongery for window [8800%] |
| 137 | glass | 1d | 2012-09-26 | 2012-09-26 | 136 | General Labour [200%]; Glazing compound [3800%]; Glazing strip and silicon topping 0.1-0.5m2 [2600%]; Glazing strip and silicon topping 0.5-1m2 [3400%]; Skill Worker [200%] |
| 138 | **Door** | 11d | 2012-09-11 | 2012-09-25 |  |  |
| 139 | **ground floor** | 2d | 2012-09-11 | 2012-09-12 |  |  |
| 140 | frame installation | 1d | 2012-09-11 | 2012-09-11 | 133SS | General Labour [200%]; Mild steel door frame 320 girth [6200%] |
| 141 | door installation | 1d | 2012-09-12 | 2012-09-12 | 140 | Door 800x2100x38mm Type P10 [400%]; Door 900x2100x38mm Type P5 [400%]; Door 900x2100x40mm Type P4 [1000%]; Door 600x2100x40mm Type P10a [200%]; Panelled Door 900x2100x40mm Type P3 [200%]; Ironmongery for door [15800%]; Ironworker [300%]; General Labour [200%] |
| 142 | **1st floor** | 2d | 2012-09-24 | 2012-09-25 |  |  |
| 143 | frame installation | 1d | 2012-09-24 | 2012-09-24 | 136SS | General Labour [200%]; Mild steel door frame 320 girth [6200%] |
| 144 | door installation | 1d | 2012-09-25 | 2012-09-25 | 143 | General Labour [200%]; Door 800x2100x38mm Type P10 [400%]; Door 900x2100x38mm Type P5 [400%]; Door 900x2100x40mm Type P4 [1000%]; Door 600x2100x40mm Type P10a [200%]; Ironmongery for door [15800%]; Ironworker [300%]; Panelled Door 900x2100x40mm Type P3 [200%] |
| 145 | **INTERNAL WORK** | 46d | 2012-09-11 | 2012-11-13 |  |  |
| 146 | **Roof** | 5d | 2012-10-19 | 2012-10-25 |  |  |
| 147 | Steel Truss Fabricated Installation | 1d | 2012-10-19 | 2012-10-19 | 110 | PATENTED' roof trusses [200%]; Roofer; General Labour [400%] |
| 148 | Boarding and Flooring | 2d | 2012-10-22 | 2012-10-23 | 147 | General Labour [200%]; Wrot pressure treated Group B timber 200mm x 25mm [2400%]; Wrot pressure treated Group B timber 300mm x 25mm [23800%]; Wrot pressure treated Group B timber 75mm x 50mm Tie [1200%]; Wrot pressure treated Group B timber 100mm x 75mm Wall Plate [9400%]; Carpenter and Joiner [200%] |
| 149 | Painting Woodwork | 2d | 2012-10-24 | 2012-10-25 | 148 | Painter [200%]; Prime and enamel paint - 150mm-300mm Girth [3600%]; Prime and enamel paint - Over 300mm Girth [7800%] |
| 150 | **M&E** | 11d | 2012-09-11 | 2012-09-25 |  |  |
| 151 | Conduit | 6d | 2012-09-11 | 2012-09-18 | 119SS, 122SS, 126SS, 129SS | Electrician; Electrical Tools [400%] |
| 152 | Wiring | 3d | 2012-09-19 | 2012-09-21 | 151 | Electrical Tools [500%]; Wiringman [200%] |
| 153 | Fitting | 2d | 2012-09-24 | 2012-09-25 | 152 | Electrical Tools [200%]; Electrician |
| 154 | **Sanitary Installation** | 14d | 2012-09-26 | 2012-10-15 |  |  |
| 155 | Sanitary Fitting | 14d | 2012-09-26 | 2012-10-15 | 153 | sanitary basin [400%]; Sanitary close couple wash down [400%]; Sanitary floor trap [1000%]; Sanitary hand bidet set complete [600%]; Sanitary miror [600%]; Sanitary Semi recessed soup dish [200%]; Sanitary shower [600%]; Sanitary sink [400%]; Sanitary soup holder [400%]; Sanitary tap and hand bidet [200%]; Sanitary toilet roll holder [600%]; Sanitary towel rail [600%]; Sanitary water closet [200%]; Sanitary water trough [200%]; Skill Worker [200%] |
| 156 | **Plumbing Installation** | 10d | 2012-10-16 | 2012-10-29 |  |  |
| 157 | Cold Water Systems | 2d | 2012-10-16 | 2012-10-17 | 155 | Cold water system; Skill Worker |
| 158 | Storage Water Tank | 2d | 2012-10-18 | 2012-10-19 | 157SS+2d | Storage water tank; General Labour [200%] |
| 159 | Sanitary Pipe Installation | 2d | 2012-10-22 | 2012-10-23 | 158SS+2d | Sanitary appliances; Skill Worker |
| 160 | Testing Pipework | 4d | 2012-10-24 | 2012-10-29 | 157, 158, 159 | Testing plumbing; Skill Worker |
| 161 | **Finishes** | 32d | 2012-09-14 | 2012-10-29 |  |  |
| 162 | **Wall** | 24d | 2012-09-14 | 2012-10-17 |  |  |
| 163 | **ground floor** | 15d | 2012-09-14 | 2012-10-04 |  |  |
| 164 | Plastering | 7d | 2012-09-14 | 2012-09-24 | 123, 134, 141 | Pavior/Plasterer [200%]; Half brickwall 1:6 [17600%] |
| 165 | Tile Installation | 5d | 2012-09-25 | 2012-10-01 | 164 | 200 x 200 x 7mm glazed walls tiles [4600%]; Tile Fixer |
| 166 | **painting** | 3d | 2012-10-02 | 2012-10-04 |  |  |
| 167 | Under coat | 1d | 2012-10-02 | 2012-10-02 | 165 | Painter; Paint finishing coat [9000%] |
| 168 | Finishing Coat | 2d | 2012-10-03 | 2012-10-04 | 167 | Paint finishing coat [9000%]; Painter |
| 169 | **first floor** | 15d | 2012-09-27 | 2012-10-17 |  |  |
| 170 | Plastering | 7d | 2012-09-27 | 2012-10-05 | 130, 137, 144 | Pavior/Plasterer [200%]; Half brickwall 1:6 [400%] |
| 171 | Tile Installation | 5d | 2012-10-08 | 2012-10-12 | 170 | Tile Fixer; 300 x 300 x 8.5mm non slipt heavy duty homogeneius tiles [4600%] |
| 172 | **painting** | 3d | 2012-10-15 | 2012-10-17 |  |  |
| 173 | Under coat | 1d | 2012-10-15 | 2012-10-15 | 171 | Painter; Paint finishing coat [9000%] |
| 174 | Finishing Coat | 2d | 2012-10-16 | 2012-10-17 | 173 | Paint finishing coat [9000%]; Painter |
| 175 | **Ceiling** | 16d | 2012-09-25 | 2012-10-16 |  |  |
| 176 | **ground floor** | 7d | 2012-09-25 | 2012-10-03 |  |  |
| 177 | Plastering | 3d | 2012-09-25 | 2012-09-27 | 164 | Pavior/Plasterer; plastering 16mm thick 1:6 [30000%] |
| 178 | **painting** | 3d | 2012-09-28 | 2012-10-02 |  |  |
| 179 | Under Coat | 1d | 2012-09-28 | 2012-09-28 | 177 | Paint finishing coat [9000%]; Painter |
| 180 | Finishing Coat | 2d | 2012-10-01 | 2012-10-02 | 179 | Paint finishing coat [9000%]; Painter |
| 181 | Cleaning | 1d | 2012-10-03 | 2012-10-03 | 180 | General Labour |
| 182 | **first floor** | 7d | 2012-10-08 | 2012-10-16 |  |  |
| 183 | Lining | 2d | 2012-10-08 | 2012-10-09 | 170 | Ceiling linning [3000%]; General Labour |
| 184 | Ceiling Board | 1d | 2012-10-10 | 2012-10-10 | 183 | Ceiling installment [3000%]; Skill Worker |
| 185 | **painting** | 3d | 2012-10-11 | 2012-10-15 |  |  |
| 186 | Under Coat | 1d | 2012-10-11 | 2012-10-11 | 184 | Painter; Paint finishing coat [3000%] |
| 187 | Finishing Coat | 2d | 2012-10-12 | 2012-10-15 | 186 | Paint finishing coat [3000%]; Painter |
| 188 | Cleaning | 1d | 2012-10-16 | 2012-10-16 | 187 | General Labour |
| 189 | **Floor** | 18d | 2012-10-04 | 2012-10-29 |  |  |
| 190 | **ground floor** | 6.5d | 2012-10-04 | 2012-10-12 |  |  |
| 191 | Rendering | 1d | 2012-10-04 | 2012-10-04 | 181 | Half brickwall 1:3 [3000%]; General Labour [200%] |
| 192 | Water Proofing | 1d | 2012-10-04 | 2012-10-04 | 191FF | Water proofing [600%]; Skill Worker [200%] |
| 193 | Tile Installation | 2.5d | 2012-10-05 | 2012-10-09 | 192 | Tile Fixer [200%]; 300 x 300 x 8.5mm non slipt heavy duty homogeneius tiles [3600%]; Ceramic Floor Tile [3400%]; Homogenous Floor Tiles [3000%] |
| 194 | Skirting | 2d | 2012-10-09 | 2012-10-11 | 193 | General Labour; Skirting 100mm high [10000%] |
| 195 | Cleaning | 1d | 2012-10-11 | 2012-10-12 | 194 | General Labour |
| 196 | **first floor** | 9d | 2012-10-17 | 2012-10-29 |  |  |
| 197 | Rendering | 1d | 2012-10-17 | 2012-10-17 | 188 | General Labour; Half brickwall 1:3 [3000%] |
| 198 | Water Proofing | 1d | 2012-10-17 | 2012-10-17 | 197FF | Water proofing [600%]; General Labour [200%] |
| 199 | Tile Installation | 5d | 2012-10-18 | 2012-10-24 | 198 | 300 x 300 x 8.5mm non slipt heavy duty homogeneius tiles [2600%]; Tile Fixer; Homogenous Floor Tiles [3400%] |
| 200 | Skirting | 2d | 2012-10-25 | 2012-10-26 | 199 | General Labour; Skirting 100mm high [7800%] |
| 201 | Cleaning | 1d | 2012-10-29 | 2012-10-29 | 200 | General Labour |
| 202 | **Cabinet Installation** | 9d | 2012-10-30 | 2012-11-09 |  |  |
| 203 | Cabinet Fitting | 5d | 2012-10-30 | 2012-11-05 | 168, 181, 188, 195, 201, 174 | Cabinet Type BT 1 [600%]; Cabinet Type B 13 [400%]; Cabinet Type B 15 [400%]; Cabinet Type G 8 [400%]; Cabinet Type KK 2 [200%]; Cabinet Type KK 6 [200%]; Cabinet Type RM 1 [200%]; Cabinet Type RT 1 [400%]; cabinet Type S 18 [400%]; Skill Worker [200%] |
| 204 | Furnishing | 4d | 2012-11-06 | 2012-11-09 | 203 | Furnishing Concrete Base Grade 30; Furnishing Concrete Base REF A6 [400%]; Furnishing Concrete Based Class F1 [400%]; Skill Worker |
| 205 | **Wardrobe Installation** | 11d | 2012-10-30 | 2012-11-13 |  |  |
| 206 | Wardrobe Fitting | 3d | 2012-10-30 | 2012-11-01 | 203SS | Wardrobe Type BT 5 [200%]; Wardrobe Type KT 6 [200%]; Skill Worker |
| 207 | Furnishing | 2d | 2012-11-12 | 2012-11-13 | 206, 204FF+2d | Furnishing Concrete Base Grade 30; Furnishing Concrete Base REF A6 [400%]; Furnishing Concrete Based Class F1 [400%]; Skill Worker |
| 208 | **EXTERNAL WORK** | 52d | 2012-09-12 | 2012-11-22 |  |  |
| 209 | **Roof** | 8d | 2012-10-26 | 2012-11-06 |  |  |
| 210 | Roof Tiles installation | 3d | 2012-10-26 | 2012-10-30 | 149 | Roofer [200%]; General Labour [400%]; Roofing concrete interlocking tiles Sloping [70200%]; Roofing concrete interlocking tiles Valley tiles [5200%]; Roofing concrete interlocking tiles Ridge tiles [2800%]; Roofing concrete interlocking tiles Hip tiles [9400%]; Roofing concrete interlocking tiles 3 way apex [400%]; ALLUMINIUM FOIL [70200%] |
| 211 | Gutterwork | 2d | 2012-10-31 | 2012-11-01 | 210 | General Labour [400%]; UPVC box gutters and fitting [7400%] |
| 212 | Pipework | 3d | 2012-11-02 | 2012-11-06 | 211 | Plumber [300%]; 100mm diam UPVC [5400%] |
| 213 | **Drainage** | 4d | 2012-11-07 | 2012-11-12 |  |  |
| 214 | Drains | 3d | 2012-11-07 | 2012-11-09 | 212 | Excavator; Excavator Operator |
| 215 | Sump | 1d | 2012-11-12 | 2012-11-12 | 214 | General Labour; Concrete G15 [200%]; Bricklayer [1000%] |
| 216 | **Sewerage** | 4d | 2012-11-13 | 2012-11-16 |  |  |
| 217 | Precast Concrete Manhole | 2d | 2012-11-13 | 2012-11-14 | 215 | Skill Worker [200%]; Concrete G 30 [200%] |
| 218 | Manhole Cover Installation | 2d | 2012-11-15 | 2012-11-16 | 217 | General Labour |
| 219 | **Water Reticulation System** | 4d | 2012-11-19 | 2012-11-22 |  |  |
| 220 | Pipe Laying | 3d | 2012-11-19 | 2012-11-21 | 218 | Plumber; 100mm diam UPVC [500%] |
| 221 | Valves Installation | 1d | 2012-11-22 | 2012-11-22 | 220, 160 | General Labour |
| 222 | **M&E** | 2d | 2012-09-26 | 2012-09-27 |  |  |
| 223 | TNB Cable Laying | 2d | 2012-09-26 | 2012-09-27 | 153 | Electrician |
| 224 | **Finishes** | 26d | 2012-09-12 | 2012-10-17 |  |  |
| 225 | **Wall** | 19d | 2012-09-12 | 2012-10-08 |  |  |
| 226 | **ground floor** | 11d | 2012-09-12 | 2012-09-26 |  |  |
| 227 | Plastering | 7d | 2012-09-12 | 2012-09-20 | 123FS+1d | Pavior/Plasterer [200%]; plastering 16mm thick 1:6 [5000%] |
| 228 | Water Proofing | 1d | 2012-09-20 | 2012-09-20 | 227FF | General Labour [200%]; Water proofing [3000%] |
| 229 | **painting** | 3d | 2012-09-21 | 2012-09-25 |  |  |
| 230 | Under Coat | 1d | 2012-09-21 | 2012-09-21 | 228 | Painter [400%] |
| 231 | Finishing Coat | 2d | 2012-09-24 | 2012-09-25 | 230 | Painter; Paint finishing coat [3000%] |
| 232 | Cleaning | 1d | 2012-09-26 | 2012-09-26 | 231 | General Labour |
| 233 | **first floor** | 11d | 2012-09-24 | 2012-10-08 |  |  |
| 234 | Plastering | 7d | 2012-09-24 | 2012-10-02 | 130FS+1d | Pavior/Plasterer [200%]; plastering 16mm thick 1:6 [2000%] |
| 235 | Water Proofing | 1d | 2012-10-02 | 2012-10-02 | 234FF | General Labour; Water proofing [2500%] |
| 236 | **painting** | 3d | 2012-10-03 | 2012-10-05 |  |  |
| 237 | Under Coat | 1d | 2012-10-03 | 2012-10-03 | 235 | Painter [300%] |
| 238 | Finishing Coat | 2d | 2012-10-04 | 2012-10-05 | 237 | Painter [200%]; Paint finishing coat [2500%] |
| 239 | Cleaning | 1d | 2012-10-08 | 2012-10-08 | 238 | General Labour |
| 240 | **Ceiling** | 11d | 2012-09-27 | 2012-10-11 |  |  |
| 241 | **ground floor** | 6d | 2012-09-27 | 2012-10-04 |  |  |
| 242 | Plastering | 3d | 2012-09-27 | 2012-10-01 | 232 | Pavior/Plasterer [200%]; plastering 16mm thick 1:6 [2500%] |
| 243 | **painting** | 3d | 2012-10-02 | 2012-10-04 |  |  |
| 244 | Under Coat | 1d | 2012-10-02 | 2012-10-02 | 242 | Painter [200%] |
| 245 | Finishing Coat | 2d | 2012-10-03 | 2012-10-04 | 244 |  |
| 246 | **first floor** | 3d | 2012-10-09 | 2012-10-11 |  |  |
| 247 | Lining | 2d | 2012-10-09 | 2012-10-10 | 170FS+1d, 239 | Ceiling linning [3400%]; General Labour [200%] |
| 248 | Ceiling Board | 1d | 2012-10-11 | 2012-10-11 | 247 | Ceiling installment [2400%]; General Labour [200%] |
| 249 | **Floor** | 9d | 2012-10-05 | 2012-10-17 |  |  |
| 250 | **ground Floor** | 9d | 2012-10-05 | 2012-10-17 |  |  |
| 251 | Rendering | 1d | 2012-10-05 | 2012-10-05 | 191SS, 245 | General Labour; Half brickwall 1:3 [3000%] |
| 252 | Water Proofing | 1d | 2012-10-05 | 2012-10-05 | 251FF | Water proofing [500%]; General Labour |
| 253 | Tiling | 5d | 2012-10-08 | 2012-10-12 | 252 | Tile Fixer; 300 x 300 x 8.5mm non slipt heavy duty homogeneius tiles [2000%] |
| 254 | Skirting | 2d | 2012-10-15 | 2012-10-16 | 253 | General Labour; Skirting 100mm high [3600%] |
| 255 | Cleaning | 1d | 2012-10-17 | 2012-10-17 | 254 | General Labour |
| 256 | End | 0d | 2012-11-22 | 2012-11-22 | 116, 248, 255, 207, 223, 221 |  |

Removed: 4 manufacture; 16 columnB 8; 17 columnA 8; 18 galleryhouse

Changed:

| ID | Task | Start | Finish | Duration | Total float | Predecessors | Other |
| --- | --- | --- | --- | --- | --- | --- | --- |
| 2 | **PRELIMINARY WORK** | 2010-06-29 → 2012-01-02 (+552d) | 2010-07-30 → 2012-01-25 (+544d) | 24d → 18d | 8d → 0d |  | was named footgrid A; resources labour; manager; concrete → none; baseline start none → 2012-04-23; baseline finish none → 2012-11-22 |
| 3 | site investigation | 2010-06-29 → 2012-01-02 (+552d) | 2010-11-05 → 2012-01-19 (+440d) | 94d → 14d |  |  | was named basement; resources labour; manager; concrete → Site Investigation; baseline start none → 2012-04-23; baseline finish none → 2012-09-21 |
| 4 | **Temporary work** | 2010-08-02 → 2012-01-20 (+536d) | 2010-09-14 → 2012-01-25 (+498d) | 32d → 4d | 8d → 0d | 2 → none | was named footgridB; resources labour; manager; concrete → none; baseline start none → 2012-11-05; baseline finish none → 2012-11-22 |
| 5 | temporary existing road | 2010-08-02 → 2012-01-20 (+536d) | 2010-08-20 → 2012-01-20 (+518d) | 15d → 1d | 27d → 0d | 2 → 3 | was named columnA 0; resources labour; manager; concrete → General Labour [400%]; Compactor; Skill Worker; baseline start none → 2012-11-05; baseline finish none → 2012-11-07 |
| 6 | signbord work | 2010-09-15 → 2012-01-20 (+492d) | 2010-10-12 → 2012-01-20 (+465d) | 20d → 1d | 8d → 0d | 4 → 5SS | was named footgridC; resources labour; manager; concrete → Signboard; General Labour; baseline start none → 2012-11-05; baseline finish none → 2012-11-09 |
| 7 | store building | 2010-09-15 → 2012-01-20 (+492d) | 2010-10-08 → 2012-01-20 (+469d) | 18d → 1d | 10d → 0d | 4, 5 → 6SS | was named columnB 0; resources labour; manager; concrete → General Labour [300%]; Timber [600%]; Plywood [500%]; baseline start none → 2012-11-05; baseline finish none → 2012-11-07 |
| 8 | parking | 2010-10-13 → 2012-01-20 (+464d) | 2010-10-28 → 2012-01-20 (+449d) | 12d → 1d | 8d → 0d | 6, 7 → 7SS | was named columnC 0; resources labour; manager; concrete → Compactor; General Labour [200%]; Skill Worker; baseline start none → 2012-11-05; baseline finish none → 2012-11-06 |
| 9 | house workers | 2010-10-13 → 2012-01-20 (+464d) | 2010-11-23 → 2012-01-23 (+426d) | 30d → 2d | 12d → 0d | 6, 7 → 8SS | was named galfloor; resources labour; concrete → Timber [1500%]; Plywood [1200%]; General Labour [400%]; baseline start none → 2012-11-05; baseline finish none → 2012-11-13 |
| 10 | toilet, electrical and water supply | 2010-11-08 → 2012-01-20 (+438d) | 2011-01-04 → 2012-01-24 (+385d) | 42d → 3d | 2d → 0d | 3, 8 → 9SS | was named hall office floor; resources labour; concrete → General Labour [200%]; Electrician; Electrical Tools; baseline start none → 2012-11-05; baseline finish none → 2012-11-22 |
| 11 | cabin | 2010-11-08 → 2012-01-25 (+443d) | 2010-12-09 → 2012-01-25 (+412d) | 24d → 1d |  | 3, 7, 6 → 10 | was named hall access floor; resources labour; concrete → Site Office; General Labour [200%]; baseline start none → 2012-11-05; baseline finish none → 2012-11-13 |
| 12 | **SITE WORK** | 2010-12-10 → 2012-01-26 (+412d) | 2011-01-06 → 2012-02-22 (+412d) |  |  | 9, 11 → none | was named columnB 4; resources labour; manager; concrete → none; baseline start none → 2012-11-26; baseline finish none → 2013-02-04 |
| 13 | **Site Preparation** | 2011-01-07 → 2012-01-26 (+384d) | 2011-02-01 → 2012-01-31 (+364d) | 18d → 4d |  | 10, 12 → none | was named columnC 4; resources labour; manager; concrete → none; baseline start none → 2012-11-26; baseline finish none → 2012-12-04 |
| 14 | site clearance | 2011-02-02 → 2012-01-26 (+358d) | 2011-02-21 → 2012-01-27 (+340d) | 14d → 2d |  | 13, manufacture → 11 | was named erectpre; resources labour; manager; concrete; mobile crane → General Labour [200%]; Backhoe; Backhoe Driver; Lorry; baseline start none → 2012-12-07; baseline finish none → 2012-12-11 |
| 15 | stripping soil | 2010-06-29 → 2012-01-30 (+580d) | 2011-05-06 → 2012-01-31 (+270d) | 224d → 2d |  | none → 14 | was named tutorial 1; resources none → Backhoe; Backhoe Driver; Dumper; Dumper Driver; General Labour; baseline start none → 2012-12-17; baseline finish none → 2012-12-19 |
